# NearlyFree Employee Orientation Project

Schedule from MS Project, 2007-10-09 to 2008-02-20, costs in $, A marks actual dates.

## Calendars

- NearlyFree: Mon-Fri 08:00-12:00, 13:00-17:00; Sat-Sun off. Exceptions (off unless hours are given): 2007-11-22 to 2007-11-23, 2007-12-24 to 2007-12-25, 2008-01-01.

## Resources

| Resource | Group | Rate |
| --- | --- | --- |
| Tom Johansen Webmaster | Hourly | 25 |
| Alice Yee Software Specialist | Hourly | 30 |
| John Sachs Quality Assurance Admin | Hourly | 25 |
| Cheryl Gladstone HR Manager | Salary | 50 |
| Jennifer Beal Project Sponsor | Salary | 50 |
| PM Jones | Salary | 30 |

## Schedule

| ID | WBS | Task | Type | Duration | Start | Finish | Predecessors | Complete | Remaining | Baseline start | Baseline finish | Baseline duration | Total slack | Free slack | Constraint | Resources | Work | Actual work | Cost | Baseline cost | Actual cost |
| --- | --- | --- | --- | --- | --- | --- | --- | --- | --- | --- | --- | --- | --- | --- | --- | --- | --- | --- | --- | --- | --- |
| 1 | 1 | **NearlyFree Employee Orientation Project** |  | 92d? | 2007-10-09 A | 2008-02-20 |  | 43% | 52.04d? | 2007-10-09 | 2008-02-20 | 92d? | 0d |  |  |  | 992h | 670h | 30,380 | 22,300 | 20,453.95 |
| 2 | 1.1 | **Initiating** |  | 1d? | 2007-10-09 A | 2007-10-09 A |  | 100% |  | 2007-10-09 | 2007-10-09 | 1d? |  |  |  |  |  |  |  |  |  |
| 3 | 1.1.1 | Develop project charter |  | 1d? | 2007-10-09 A | 2007-10-09 A |  | 100% |  | 2007-10-09 | 2007-10-09 | 1d? |  |  |  |  |  |  |  |  |  |
| 4 | 1.1.2 | Review charter |  | 1d? | 2007-10-09 A | 2007-10-09 A |  | 100% |  | 2007-10-09 | 2007-10-09 | 1d? |  |  |  |  |  |  |  |  |  |
| 5 | 1.1.3 | Charter signed | milestone | 0d | 2007-10-09 A | 2007-10-09 A |  | 100% |  | 2007-10-09 | 2007-10-09 | 0d |  |  |  |  |  |  |  |  |  |
| 6 | 1.2 | **Planning** |  | 17d | 2007-10-10 A | 2007-11-01 A |  | 100% |  | 2007-10-09 | 2007-10-15 | 4.5d |  |  |  | PM Jones | 272h | 272h | 8,160 | 2,160 | 8,160 |
| 7 | 1.2.1 | Develop project plan |  | 16d | 2007-10-10 A | 2007-10-31 A |  | 100% |  | 2007-10-09 | 2007-10-11 | 3d |  |  | start no earlier than 2007-10-10 | PM Jones | 128h | 128h | 3,840 | 720 | 3,840 |
| 8 | 1.2.2 | Review project plan |  | 1d | 2007-11-01 A | 2007-11-01 A | 7 | 100% |  | 2007-10-12 | 2007-10-12 | 1d |  |  |  | PM Jones | 8h | 8h | 240 | 240 | 240 |
| 9 | 1.2.3 | Project plan approved | milestone | 0d | 2007-11-01 A | 2007-11-01 A | 8 | 100% |  | 2007-10-12 | 2007-10-12 | 0d |  |  |  | PM Jones |  |  |  |  |  |
| 10 | 1.2.4 | Kickoff Meeting | milestone | 0d | 2007-11-01 A | 2007-11-01 A | 9 | 100% |  | 2007-10-15 | 2007-10-15 | 0.5d |  |  |  | PM Jones |  |  |  | 120 |  |
| 11 | 1.3 | **Executing** |  | 53d | 2007-11-01 A | 2008-01-21 | 2 | 65% | 18.39d | 2007-10-15 | 2007-12-26 | 48d | 21.5d |  |  |  | 712h | 398h | 21,980 | 19,900 | 12,293.95 |
| 12 | 1.3.1 | Interface Requirement |  | 3d | 2007-11-02 A | 2007-11-06 A | 10 | 100% |  | 2007-10-15 | 2007-10-18 | 3d |  |  | start no earlier than 2007-11-02 | Tom Johansen Webmaster | 24h | 24h | 600 | 600 | 600 |
| 13 | 1.3.2 | Software Requirement |  | 4d | 2007-11-01 A | 2007-11-06 A | 10 | 100% |  | 2007-10-15 | 2007-10-17 | 2d |  |  |  | Alice Yee Software Specialist | 32h | 32h | 960 | 480 | 960 |
| 14 | 1.3.3 | User Documentation |  | 2d | 2007-11-07 A | 2007-11-08 A | 13 | 100% |  | 2007-10-17 | 2007-10-19 | 2d |  |  |  | Alice Yee Software Specialist | 16h | 16h | 480 | 480 | 480 |
| 15 | 1.3.4 | Training Materials |  | 6d | 2007-11-09 A | 2007-11-16 A | 14 | 100% |  | 2007-10-19 | 2007-10-23 | 2d |  |  | finish no earlier than 2007-11-16 | Cheryl Gladstone HR Manager | 48h | 48h | 2,400 | 800 | 2,400 |
| 16 | 1.3.5 | Product Requirements Review Meeting |  | 0.5d | 2007-11-19 A | 2007-11-19 A | 15 | 100% |  | 2007-10-23 | 2007-10-23 | 0.5d |  |  |  | PM Jones; Tom Johansen Webmaster; Alice Yee Software Specialist; John Sachs Quality Assurance Admin; Cheryl Gladstone HR Manager | 20h | 20h | 640 | 640 | 640 |
| 17 | 1.3.6 | **Construction** |  | 30.5d | 2007-11-19 A | 2008-01-07 |  | 68% | 9.84d | 2007-10-24 | 2007-12-12 | 33.5d | 21.5d | 0d |  |  | 392h | 258h | 11,280 | 11,280 | 7,213.95 |
| 18 | 1.3.6.1 | **Develop Software Application** |  | 26.5d | 2007-11-19 A | 2008-01-01 |  | 74% | 7.02d | 2007-10-24 | 2007-12-06 | 29.5d | 21.7d |  |  |  | 360h | 256.4h | 10,000 | 10,000 | 7,149.95 |
| 19 | 1.3.6.1.1 | Analyze Interface Needs |  | 2d | 2007-11-19 A | 2007-11-21 A | 16 | 100% |  | 2007-10-24 | 2007-10-25 | 2d |  |  |  | Tom Johansen Webmaster | 16h | 16h | 400 | 400 | 400 |
| 20 | 1.3.6.1.2 | Analyze Software Needs |  | 2d | 2007-11-19 A | 2007-11-21 A | 16 | 100% |  | 2007-10-24 | 2007-10-25 | 2d |  |  |  | Alice Yee Software Specialist | 16h | 16h | 480 | 480 | 480 |
| 21 | 1.3.6.1.3 | Write Interface Specs |  | 10d | 2007-11-21 A | 2007-12-05 A | 20 | 100% |  | 2007-10-26 | 2007-11-08 | 10d |  |  |  | Tom Johansen Webmaster | 80h | 80h | 2,000 | 2,000 | 2,000 |
| 22 | 1.3.6.1.4 | Write Software Specs |  | 10d | 2007-11-21 A | 2007-12-05 A | 20 | 100% |  | 2007-10-26 | 2007-11-08 | 10d |  |  |  | Alice Yee Software Specialist | 80h | 80h | 2,400 | 2,400 | 2,400 |
| 23 | 1.3.6.1.5 | Code Software Application |  | 10d | 2007-12-05 A | 2007-12-19 | 22 | 64% | 3.55d | 2007-11-09 | 2007-11-22 | 10d | 20.23d | 0d |  | Alice Yee Software Specialist | 80h | 51.6h | 2,400 | 2,400 | 1,547.95 |
| 24 | 1.3.6.1.6 | Develop Interface |  | 5d | 2007-12-19 A | 2007-12-26 | 23 | 30% | 3.5d | 2007-11-23 | 2007-11-29 | 5d | 20.73d | 0d |  | Tom Johansen Webmaster | 40h | 12h | 1,000 | 1,000 | 300 |
| 25 | 1.3.6.1.7 | Test Interface |  | 2d | 2007-12-26 | 2007-12-28 | 24 |  |  | 2007-11-30 | 2007-12-03 | 2d | 20.73d | 0d |  | Tom Johansen Webmaster | 16h |  | 400 | 400 |  |
| 26 | 1.3.6.1.8 | Test Software Application |  | 2d | 2007-12-28 | 2008-01-01 | 25 |  |  | 2007-12-04 | 2007-12-05 | 2d | 20.73d | 0d |  | Alice Yee Software Specialist | 16h |  | 480 | 480 |  |
| 27 | 1.3.6.1.9 | Application Development Review Meeting |  | 0.5d | 2008-01-01 A | 2008-01-01 | 26 | 5% | 0.47d | 2007-12-06 | 2007-12-06 | 0.5d | 21.7d | 0d |  | PM Jones; Tom Johansen Webmaster; Alice Yee Software Specialist; John Sachs Quality Assurance Admin | 16h | 0.8h | 440 | 440 | 22 |
| 28 | 1.3.6.2 | Develop User Documentation |  | 2d | 2008-01-02 A | 2008-01-03 | 27 | 5% | 1.9d | 2007-12-06 | 2007-12-10 | 2d | 21.6d | 0d |  | Alice Yee Software Specialist | 16h | 0.8h | 480 | 480 | 24 |
| 29 | 1.3.6.3 | Develop Training Materials |  | 2d | 2008-01-04 A | 2008-01-07 | 28 | 5% | 1.9d | 2007-12-10 | 2007-12-12 | 2d | 21.5d | 0d |  | Cheryl Gladstone HR Manager | 16h | 0.8h | 800 | 800 | 40 |

| ID | WBS | Task | Type | Duration | Start | Finish | Predecessors | Complete | Remaining | Baseline start | Baseline finish | Baseline duration | Total slack | Free slack | Constraint | Resources | Work | Cost | Baseline cost |
| --- | --- | --- | --- | --- | --- | --- | --- | --- | --- | --- | --- | --- | --- | --- | --- | --- | --- | --- | --- |
| 30 | 1.3.7 | **Integration and Testing** |  | 6.5d | 2008-01-08 | 2008-01-16 | 17 |  |  | 2007-12-12 | 2007-12-20 | 6.5d | 21.5d | 0d |  |  | 64h | 1,640 | 1,640 |
| 31 | 1.3.7.1 | Put Application on Intranet |  | 3d | 2008-01-08 | 2008-01-10 | 29 |  |  | 2007-12-12 | 2007-12-17 | 3d | 21.5d | 0d |  | Tom Johansen Webmaster | 24h | 600 | 600 |
| 32 | 1.3.7.2 | Quality Assurance Test |  | 3d | 2008-01-11 | 2008-01-15 | 31 |  |  | 2007-12-17 | 2007-12-20 | 3d | 21.5d | 0d |  | John Sachs Quality Assurance Admin | 24h | 600 | 600 |
| 33 | 1.3.7.3 | Integraton and Testing Review Meeting |  | 0.5d | 2008-01-16 | 2008-01-16 | 32 |  |  | 2007-12-20 | 2007-12-20 | 0.5d | 21.5d | 0d |  | PM Jones; John Sachs Quality Assurance Admin; Tom Johansen Webmaster; Alice Yee Software Specialist | 16h | 440 | 440 |
| 34 | 1.3.8 | **Training** |  | 3.5d | 2008-01-16 | 2008-01-21 | 30 |  |  | 2007-12-21 | 2007-12-26 | 1.5d | 21.5d |  |  |  | 116h | 3,980 | 3,980 |
| 35 | 1.3.8.1 | Software Training for HR |  | 3d | 2008-01-16 | 2008-01-21 | 33 |  |  | 2007-12-21 | 2007-12-25 | 3d | 21.5d | 0d |  | Tom Johansen Webmaster; Alice Yee Software Specialist; Cheryl Gladstone HR Manager; PM Jones | 96h | 3,240 | 3,240 |
| 36 | 1.3.8.2 | Training Review Meeting |  | 0.5d | 2008-01-21 | 2008-01-21 | 35 |  |  | 2007-12-26 | 2007-12-26 | 0.5d | 21.5d | 0d |  | Tom Johansen Webmaster; Alice Yee Software Specialist; Cheryl Gladstone HR Manager; Jennifer Beal Project Sponsor; PM Jones | 20h | 740 | 740 |
| 37 | 1.4 | **Controlling** |  | 89d | 2007-10-12 A | 2008-02-20 |  |  | 89d | 2007-10-12 | 2008-02-20 | 89d | 0d |  |  |  |  |  |  |
| 38 | 1.4.1 | **Status Report** |  | 80d | 2007-10-12 A | 2008-02-08 |  |  | 80d | 2007-10-12 | 2008-02-08 | 80d | 9d |  |  |  |  |  |  |
| 39 | 1.4.1.1 | Status Report 1 | milestone | 0h | 2007-10-12 A | 2007-10-12 A |  | 100% |  | 2007-10-12 | 2007-10-12 | 0h |  |  | start no earlier than 2007-10-12 |  |  |  |  |
| 40 | 1.4.1.2 | Status Report 2 | milestone | 0h | 2007-10-19 A | 2007-10-19 A |  | 100% |  | 2007-10-19 | 2007-10-19 | 0h |  |  | start no earlier than 2007-10-19 |  |  |  |  |
| 41 | 1.4.1.3 | Status Report 3 | milestone | 0h | 2007-10-26 A | 2007-10-26 A |  | 100% |  | 2007-10-26 | 2007-10-26 | 0h |  |  | start no earlier than 2007-10-26 |  |  |  |  |
| 42 | 1.4.1.4 | Status Report 4 | milestone | 0h | 2007-11-02 A | 2007-11-02 A |  | 100% |  | 2007-11-02 | 2007-11-02 | 0h |  |  | start no earlier than 2007-11-02 |  |  |  |  |
| 43 | 1.4.1.5 | Status Report 5 | milestone | 0h | 2007-11-09 A | 2007-11-09 A |  | 100% |  | 2007-11-09 | 2007-11-09 | 0h |  |  | start no earlier than 2007-11-09 |  |  |  |  |
| 44 | 1.4.1.6 | Status Report 6 | milestone | 0h | 2007-11-16 A | 2007-11-16 A |  | 100% |  | 2007-11-16 | 2007-11-16 | 0h |  |  | start no earlier than 2007-11-16 |  |  |  |  |
| 45 | 1.4.1.7 | Status Report 7 | milestone | 0h | 2007-11-23 A | 2007-11-23 A |  | 100% |  | 2007-11-23 | 2007-11-23 | 0h |  |  | start no earlier than 2007-11-23 |  |  |  |  |
| 46 | 1.4.1.8 | Status Report 8 | milestone | 0h | 2007-11-30 A | 2007-11-30 A |  | 100% |  | 2007-11-30 | 2007-11-30 | 0h |  |  | start no earlier than 2007-11-30 |  |  |  |  |
| 47 | 1.4.1.9 | Status Report 9 | milestone | 0h | 2007-12-07 A | 2007-12-07 A |  | 100% |  | 2007-12-07 | 2007-12-07 | 0h |  |  | start no earlier than 2007-12-07 |  |  |  |  |
| 48 | 1.4.1.10 | Status Report 10 | milestone | 0h | 2007-12-14 | 2007-12-14 |  |  |  | 2007-12-14 | 2007-12-14 | 0h | 46d |  | start no earlier than 2007-12-14 |  |  |  |  |
| 49 | 1.4.1.11 | Status Report 11 | milestone | 0h | 2007-12-21 | 2007-12-21 |  |  |  | 2007-12-21 | 2007-12-21 | 0h | 41d |  | start no earlier than 2007-12-21 |  |  |  |  |
| 50 | 1.4.1.12 | Status Report 12 | milestone | 0h | 2007-12-28 | 2007-12-28 |  |  |  | 2007-12-28 | 2007-12-28 | 0h | 38d |  | start no earlier than 2007-12-28 |  |  |  |  |
| 51 | 1.4.1.13 | Status Report 13 | milestone | 0h | 2008-01-04 | 2008-01-04 |  |  |  | 2008-01-04 | 2008-01-04 | 0h | 34d |  | start no earlier than 2008-01-04 |  |  |  |  |
| 52 | 1.4.1.14 | Status Report 14 | milestone | 0h | 2008-01-11 | 2008-01-11 |  |  |  | 2008-01-11 | 2008-01-11 | 0h | 29d |  | start no earlier than 2008-01-11 |  |  |  |  |
| 53 | 1.4.1.15 | Status Report 15 | milestone | 0h | 2008-01-18 | 2008-01-18 |  |  |  | 2008-01-18 | 2008-01-18 | 0h | 24d |  | start no earlier than 2008-01-18 |  |  |  |  |
| 54 | 1.4.1.16 | Status Report 16 | milestone | 0h | 2008-01-25 | 2008-01-25 |  |  |  | 2008-01-25 | 2008-01-25 | 0h | 19d |  | start no earlier than 2008-01-25 |  |  |  |  |
| 55 | 1.4.1.17 | Status Report 17 | milestone | 0h | 2008-02-01 | 2008-02-01 |  |  |  | 2008-02-01 | 2008-02-01 | 0h | 14d |  | start no earlier than 2008-02-01 |  |  |  |  |
| 56 | 1.4.1.18 | Status Report 18 | milestone | 0h | 2008-02-08 | 2008-02-08 |  |  |  | 2008-02-08 | 2008-02-08 | 0h | 9d |  | start no earlier than 2008-02-08 |  |  |  |  |
| 57 | 1.4.2 | Change reports |  | 3mo | 2007-11-26 | 2008-02-20 |  |  |  | 2007-11-26 | 2008-02-20 | 3mo | 0d |  | finish no earlier than 2008-02-20 |  |  |  |  |

| ID | WBS | Task | Duration | Start | Finish | Predecessors | Baseline start | Baseline finish | Baseline duration | Total slack | Resources | Work | Cost | Baseline cost |
| --- | --- | --- | --- | --- | --- | --- | --- | --- | --- | --- | --- | --- | --- | --- |
| 58 | 1.5 | **Project Close** | 0.5d | 2008-01-22 | 2008-01-22 | 36 | 2007-12-26 | 2007-12-26 | 0.5d | 21.5d | PM Jones | 8h | 240 | 240 |
| 59 | 1.5.1 | Post Mortem Lessons Learned | 0.5d | 2008-01-22 | 2008-01-22 |  | 2007-12-26 | 2007-12-26 | 0.5d | 21.5d | PM Jones | 4h | 120 | 120 |
